# 20220711_Programming Tool

Schedule from MS Project, 2022-07-11 to 2023-12-08.

## Calendars

- Standard: Mon-Fri 08:00-12:00, 13:00-17:00; Sat-Sun off.

## Resources

| Resource |
| --- |
| 4 |
| 5 |
| 6SS |
| 7 |
| 8FS+1 day |
| 9SS+8 days |
| 10FS-1 day |
| 11 |
| 14 |
| 15 |
| 16 |
| 17 |
| 18 |
| 19 |
| 20 |
| 21 |
| 22 |
| 23 |
| 24 |
| 25 |
| 26 |
| 27 |
| 28 |
| 29 |
| 30 |
| 32 |
| 33 |
| 34 |
| 36 |
| 37 |
| 38 |
| 39 |
| 40 |
| 41 |
| 42 |
| 43 |
| 46 |
| 47 |
| 48 |
| 49 |
| 50 |
| 51 |
| 52 |
| 53 |
| 54 |
| 55 |
| 56 |
| 57 |
| 58 |
| 60 |
| 61 |
| 62 |
| 63 |
| Proponent |
| Council |

## Schedule

| ID | WBS | Task | Type | Duration | Start | Finish | Predecessors | Total slack | Resources | Work |
| --- | --- | --- | --- | --- | --- | --- | --- | --- | --- | --- |
| 1 | 1 | **Planning Proposal - Complex** |  | 370d | 2022-07-11 | 2023-12-08 |  | 0d |  | 240h |
| 2 | 1.1 | **Stage 1 -Pre-Lodgement (max. 60 days)** |  | 50d | 2022-07-11 | 2022-09-16 |  | 0d |  | 240h |
| 3 | 1.1.1 | Prepare Scoping Proposal |  | 4w | 2022-07-11 | 2022-08-05 |  | 0d | Proponent | 160h |
| 4 | 1.1.2 | Submit scoping proposal to Council | milestone | 0d | 2022-08-05 | 2022-08-05 | 3 | 350d | Proponent |  |
| 5 | 1.1.3 | Review Pre-Lodgement Information |  | 1w | 2022-08-08 | 2022-08-12 | 3 | 0d | Council | 40h |
| 6 | 1.1.4 | Scoping proposal referred to authorities/agencies |  | 1w | 2022-08-15 | 2022-08-19 | 5 | 0d | Council | 40h |
| 7 | 1.1.5 | Pre lodgement meeting | milestone | 0d | 2022-08-19 | 2022-08-19 | 6 | 0d | Council |  |
| 8 | 1.1.6 | Council assessment |  | 2w | 2022-08-22 | 2022-09-02 | 7 | 0d |  |  |
| 9 | 1.1.7 | Council provides written feedback to Proponent confirming the points discussed |  | 1w | 2022-09-05 | 2022-09-09 | 8 | 0d |  |  |
| 10 | 1.1.8 | Liaise with Council internal teams to confirm any other matters |  | 1w | 2022-09-12 | 2022-09-16 | 9 | 0d |  |  |
| 11 | 1.1.9 | PP requirements issued | milestone | 0d | 2022-09-16 | 2022-09-16 | 10 | 0d |  |  |
| 12 | 1.2 | **Stage 2 - Planning Proposal (max. 120 days)** |  | 90d | 2023-01-06 | 2023-05-12 |  | 0d |  |  |
| 13 | 1.2.1 | PP Lodgement | milestone | 0d | 2023-01-06 | 2023-01-06 | 11FS+4mo | 0d |  |  |
| 14 | 1.2.2 | **Council Assessment** |  | 70d | 2023-01-09 | 2023-04-14 |  | 0d |  |  |
| 15 | 1.2.2.1 | Review PP against relevant planning policies |  | 1w | 2023-01-09 | 2023-01-13 | 13 | 0d |  |  |
| 16 | 1.2.2.2 | **Referral to relevant Council teams and consolidate comments** |  | 20d | 2023-01-16 | 2023-02-10 |  | 0d |  |  |
| 17 | 1.2.2.2.1 | Engineering |  | 4w | 2023-01-16 | 2023-02-10 | 15 | 0d |  |  |
| 18 | 1.2.2.2.2 | Open Space |  | 4w | 2023-01-16 | 2023-02-10 | 15 | 0d |  |  |
| 19 | 1.2.2.2.3 | Traffic |  | 4w | 2023-01-16 | 2023-02-10 | 15 | 0d |  |  |
| 20 | 1.2.2.3 | **Referral to Dept and other statutory authorities and consolidate comments** |  | 15d | 2023-01-16 | 2023-02-03 |  | 5d |  |  |
| 21 | 1.2.2.3.1 | TfNSW |  | 3w | 2023-01-16 | 2023-02-03 | 15 | 5d |  |  |
| 22 | 1.2.2.3.2 | Heritage NSW |  | 3w | 2023-01-16 | 2023-02-03 | 15 | 5d |  |  |
| 23 | 1.2.2.3.3 | SES |  | 3w | 2023-01-16 | 2023-02-03 | 15 | 5d |  |  |
| 24 | 1.2.2.4 | Review PP by General Manager |  | 4w | 2023-02-13 | 2023-03-10 | 20, 16 | 0d |  |  |
| 25 | 1.2.2.5 | Request additional information from Proponent and update PP as required |  | 4w | 2023-03-13 | 2023-04-07 | 24 | 0d |  |  |
| 26 | 1.2.2.6 | Referral to LPP |  | 1w | 2023-04-10 | 2023-04-14 | 25 | 160d |  |  |
| 27 | 1.2.3 | Councillor Briefing (if required) |  | 1w | 2023-04-10 | 2023-04-14 | 25 | 160d |  |  |
| 28 | 1.2.4 | Council officers prepare report to Council |  | 4w | 2023-04-10 | 2023-05-05 | 25 | 0d |  |  |
| 29 | 1.2.5 | Council decision to support or reject PP |  | 1w | 2023-05-08 | 2023-05-12 | 28 | 0d |  |  |
| 30 | 1.2.6 | Council submits PP to Dept for Gateway | milestone | 0d | 2023-05-12 | 2023-05-12 | 29 | 0d |  |  |

| ID | WBS | Task | Type | Duration | Start | Finish | Predecessors | Total slack |
| --- | --- | --- | --- | --- | --- | --- | --- | --- |
| 31 | 1.3 | **Stage 3 - Gateway Determination (max. 45 days)** |  | 20d | 2023-05-15 | 2023-06-09 |  | 0d |
| 32 | 1.3.1 | PP Review |  | 4w | 2023-05-15 | 2023-06-09 | 30 | 0d |
| 33 | 1.3.2 | Recommendation to Minister to Proceed | milestone | 0d | 2023-06-09 | 2023-06-09 | 32 | 120d |
| 34 | 1.3.3 | Gateway Determination issued | milestone | 0d | 2023-06-09 | 2023-06-09 | 32 | 0d |
| 35 | 1.4 | **Stage 4 - Post Gateway (max. 70 days)** |  | 45d | 2023-06-12 | 2023-08-11 |  | 0d |
| 36 | 1.4.1 | Council reviews Gateway determination and actions |  | 1w | 2023-06-12 | 2023-06-16 | 34 | 0d |
| 37 | 1.4.2 | Provide additional info and/or update PP and provide to Dept for review (if required) |  | 2w | 2023-06-19 | 2023-06-30 | 36 | 0d |
| 38 | 1.4.3 | **Undertake consultation with authorities and government agencies (if required)** |  | 15d | 2023-07-03 | 2023-07-21 |  | 0d |
| 39 | 1.4.3.1 | TfNSW |  | 3w | 2023-07-03 | 2023-07-21 | 37 | 0d |
| 40 | 1.4.3.2 | Heritage NSW |  | 3w | 2023-07-03 | 2023-07-21 | 37 | 0d |
| 41 | 1.4.3.3 | SES |  | 3w | 2023-07-03 | 2023-07-21 | 37 | 0d |
| 42 | 1.4.4 | Finalise infrastructure schedules or development contributions plan |  | 2w | 2023-07-24 | 2023-08-04 | 38 | 0d |
| 43 | 1.4.5 | Undertake pre-exhibition adminstrative tasks |  | 1w | 2023-08-07 | 2023-08-11 | 42 | 0d |
| 44 | 1.5 | **Stage 5 - Public Exhibition and Assessment (max. 115 days)** |  | 65d | 2023-08-14 | 2023-11-10 |  | 0d |
| 45 | 1.5.1 | **Council publicly exhibits PP** |  | 25d | 2023-08-14 | 2023-09-15 |  | 0d |
| 46 | 1.5.1.1 | Advertisements notifying Public Exhibition |  | 1w | 2023-08-14 | 2023-08-18 | 43 | 0d |
| 47 | 1.5.1.2 | Notification letters with attached fact sheets |  | 1w | 2023-08-14 | 2023-08-18 | 43 | 0d |
| 48 | 1.5.1.3 | Collateral for Public Exhibition |  | 1w | 2023-08-14 | 2023-08-18 | 43 | 0d |
| 49 | 1.5.1.4 | Memo to Councillors |  | 1w | 2023-08-14 | 2023-08-18 | 43 | 0d |
| 50 | 1.5.1.5 | Public Authority Consultation |  | 4w | 2023-08-21 | 2023-09-15 | 46, 47, 48, 49 | 0d |
| 51 | 1.5.1.6 | Public Exhibition Period |  | 4w | 2023-08-21 | 2023-09-15 | 46, 47, 48, 49 | 0d |
| 52 | 1.5.2 | **Review submissions and outline amendments** |  | 20d | 2023-09-18 | 2023-10-13 | 51 | 0d |
| 53 | 1.5.2.1 | Public Exhibition Summary Report |  | 2w | 2023-09-18 | 2023-09-29 | 51, 50 | 0d |
| 54 | 1.5.2.2 | Responses to Stakeholders |  | 2w | 2023-10-02 | 2023-10-13 | 53 | 0d |
| 55 | 1.5.3 | Council reviews PP and undertakes changes |  | 2w | 2023-10-16 | 2023-10-27 | 54 | 0d |
| 56 | 1.5.4 | Councillor Briefing (if required) |  | 1w | 2023-10-30 | 2023-11-03 | 55 | 25d |
| 57 | 1.5.5 | Council officers prepare report for Council Resolution |  | 2w | 2023-10-30 | 2023-11-10 | 55 | 0d |
| 58 | 1.5.6 | Supported PP referred to the Department to finalise the LEP | milestone | 0d | 2023-11-10 | 2023-11-10 | 57 | 0d |

| ID | WBS | Task | Type | Duration | Start | Finish | Predecessors | Total slack |
| --- | --- | --- | --- | --- | --- | --- | --- | --- |
| 59 | 1.6 | **Stage 6 - Finalisation (max. 70 days)** |  | 20d | 2023-11-10 | 2023-12-08 |  | 0d |
| 60 | 1.6.1 | Council resolves to make the LEP as LPMA | milestone | 0d | 2023-11-10 | 2023-11-10 | 58 | 0d |
| 61 | 1.6.2 | Prepare drafting instructions for the PCO to draft the LEP |  | 4w | 2023-11-13 | 2023-12-08 | 60 | 0d |
| 62 | 1.6.3 | Council refers mapping to the Department and issues final maps to PCO once endorsed |  | 4w | 2023-11-13 | 2023-12-08 | 60 | 0d |
| 63 | 1.6.4 | Make the LEP and request the Department arrange notification | milestone | 0d | 2023-12-08 | 2023-12-08 | 62, 61 | 0d |
| 65 | 1.6.5 | NOTE: public holidays needed to added into non-working time. Go to 'Project' Tab --> 'Change Working Time' under Properties ---> Add public holidays and Christmas shutdowns. | manual | 1d? | 2023-11-10 | 2023-11-13 |  |  |
